# Ressourcetyper

How a schedule from MS Project changed from version to version. A marks actual dates.

## Version 1 (saved 2010-10-22, file 05F - Ressourcetyper.mpp)

| ID | WBS | Task | Duration | Start | Finish | Predecessors | Total float |
| --- | --- | --- | --- | --- | --- | --- | --- |
| 1 | 1 | **Ny butik i Århus** | 27d | 2010-10-22 | 2010-11-29 |  | 0d |
| 2 |  | Tegning | 3d | 2010-10-22 | 2010-10-26 |  | 0d |
| 3 | 1.2 | **Fundament** | 6d | 2010-10-29 | 2010-11-07 | 2FS+2d | 0d |
| 4 |  | Udgravning | 2d | 2010-10-29 | 2010-11-01 |  | 0d |
| 5 |  | Støbning | 1d | 2010-11-02 | 2010-11-02 | 4 | 0d |
| 6 |  | Afbinding | 5ed | 2010-11-02 | 2010-11-07 | 5 | 1.88d |
| 7 | 1.3 | **Råhus** | 5d | 2010-11-08 | 2010-11-12 | 6 | 0d |
| 8 |  | Bærende konstruktioner | 3d | 2010-11-08 | 2010-11-10 |  | 0d |
| 9 |  | Ydervægge | 2d | 2010-11-11 | 2010-11-12 | 8 | 0d |
| 10 |  | Tag | 2d | 2010-11-11 | 2010-11-12 | 9SS | 0d |
| 11 |  | Rejsegilde | 0d | 2010-11-12 | 2010-11-12 | 10, 9 | 0d |
| 12 |  | Taglægning | 10d | 2010-11-15 | 2010-11-26 | 11 | 0d |
| 13 |  | Døre og vinduer | 2d | 2010-11-15 | 2010-11-16 | 12SS | 5d |
| 14 |  | Faskine | 2d | 2010-11-03 | 2010-11-04 | 5 | 11.12d |
| 15 |  | Tagrender | 5h | 2010-11-15 | 2010-11-15 | 14, 13SS | 5.12d |
| 16 |  | Maling udvendigt | 10h | 2010-11-15 | 2010-11-16 | 15 | 5.12d |
| 17 |  | Gulv | 1d | 2010-11-17 | 2010-11-17 | 16, 13 | 5d |
| 18 |  | Maling indvendigt | 2d | 2010-11-25 | 2010-11-26 | 17, 12FF | 0d |
| 19 |  | Indvielse | 0d | 2010-11-29 | 2010-11-29 | 18FS+1d, 13 | 0d |

## Version 2 (saved 2020-09-04, file 05A - Oprettelse af ressourcer.mpp)

Last finish 2010-11-29 → 2019-07-29 (+3164d).

Added:

| ID | Task | Duration | Start | Finish | Predecessors |
| --- | --- | --- | --- | --- | --- |
| 9 | Tagkonstruktioner | 2d | 2019-07-10 | 2019-07-12 | 8SS |

Removed: 1 Ny butik i Århus; 10 Tag

Changed:

| ID | Task | Start | Finish | Duration | Total float | Predecessors | Other |
| --- | --- | --- | --- | --- | --- | --- | --- |
| 1 | Tegning | 2010-10-22 → 2019-06-20 (+3163d) | 2010-10-26 → 2019-06-24 (+3163d) |  | 0d → 1d |  | resources Arkitekt Arne → none |
| 2 | **Fundament** | 2010-10-29 → 2019-06-27 (+3163d) | 2010-11-07 → 2019-07-06 (+3163d) | 6d → 7d |  |  |  |
| 3 | Udgravning | 2010-10-29 → 2019-06-27 (+3163d) | 2010-11-01 → 2019-06-28 (+3161d) |  | 0d → 1d |  | resources Jord og beton Jette → none |
| 4 | Støbning | 2010-11-02 → 2019-07-01 (+3163d) | 2010-11-02 → 2019-07-01 (+3163d) |  | 0d → 1d |  |  |
| 5 | Afbinding | 2010-11-02 → 2019-07-01 (+3163d) | 2010-11-07 → 2019-07-06 (+3163d) |  | 1.88d → 4.88d |  |  |
| 6 | **Råhus** | 2010-11-08 → 2019-07-08 (+3164d) | 2010-11-12 → 2019-07-12 (+3164d) | 5d → 4.25d |  | 5 → 2 |  |
| 7 | Bærende konstruktioner | 2010-11-08 → 2019-07-08 (+3164d) | 2010-11-10 → 2019-07-10 (+3164d) |  |  |  | resources Tømrer Tom → none |
| 8 | Ydervægge | 2010-11-11 → 2019-07-10 (+3163d) | 2010-11-12 → 2019-07-12 (+3164d) |  |  | 7 → 7FS-2.5% | resources Murer Mads → none |
| 10 | Rejsegilde | 2010-11-12 → 2019-07-12 (+3164d) | 2010-11-12 → 2019-07-12 (+3164d) |  |  | Tag, 8 → 6 |  |
| 11 | Taglægning | 2010-11-15 → 2019-07-12 (+3161d) | 2010-11-26 → 2019-07-26 (+3164d) |  |  |  | resources Tømrer Tom → none |
| 12 | Døre og vinduer | 2010-11-15 → 2019-07-12 (+3161d) | 2010-11-16 → 2019-07-16 (+3164d) |  | 5d → 7d |  | resources Snedker Susanne → none |
| 13 | Faskine | 2010-11-03 → 2019-07-01 (+3162d) | 2010-11-04 → 2019-07-02 (+3162d) |  | 11.12d → 15.38d | 4 → 3 | resources Jord og beton Jette → none |
| 14 | Tagrender | 2010-11-15 → 2019-07-12 (+3161d) | 2010-11-15 → 2019-07-12 (+3161d) |  | 5.12d → 8.12d |  | resources Murer Mads → none |
| 15 | Maling udvendigt | 2010-11-15 → 2019-07-25 (+3174d) | 2010-11-16 → 2019-07-26 (+3174d) |  | 5.12d → 0d | 14 → 14, 11FF | resources Maler Morten → none |
| 16 | Maling indvendigt | 2010-11-25 → 2019-07-16 (+3155d) | 2010-11-26 → 2019-07-18 (+3156d) |  | 0d → 7d | 17, 11FF → 12 | resources Maler Morten → none |
| 17 | Gulv | 2010-11-17 → 2019-07-17 (+3164d) | 2010-11-17 → 2019-07-18 (+3165d) |  | 5d → 7d | 15, 12 → 16FS-5% | resources Snedker Susanne → none |
| 18 | Indvielse | 2010-11-29 → 2019-07-29 (+3164d) | 2010-11-29 → 2019-07-29 (+3164d) |  |  | 16FS+1d, 12 → 17, 15FS+1d |  |

## Version 3 (saved 2020-09-04, file 05D - Kontrollere og redigere allokeringer.mpp)

Last finish 2019-07-29 → 2019-07-31 (+2d).

Changed:

| ID | Task | Start | Finish | Duration | Total float | Other |
| --- | --- | --- | --- | --- | --- | --- |
| 1 | Tegning |  | 2019-06-24 → 2019-06-26 (+2d) |  | 1d → 0d | resources none → Arkitekt Arne |
| 2 | **Fundament** | 2019-06-27 → 2019-06-28 (+1d) | 2019-07-06 → 2019-07-08 (+2d) | 7d → 6d |  |  |
| 3 | Udgravning | 2019-06-27 → 2019-06-28 (+1d) | 2019-06-28 → 2019-07-02 (+4d) |  | 1d → 0d | resources none → Gravemaskine; Jord og Beton Jette |
| 4 | Støbning | 2019-07-01 → 2019-07-02 (+1d) | 2019-07-01 → 2019-07-03 (+2d) |  | 1d → 0d | resources none → Beton [2 Kubikmeter]; Betonblander; Jord og Beton Jette |
| 5 | Afbinding | 2019-07-01 → 2019-07-03 (+2d) | 2019-07-06 → 2019-07-08 (+2d) |  | 4.88d → 0d |  |
| 7 | Bærende konstruktioner |  | 2019-07-10 → 2019-07-11 (+1d) |  |  | resources none → Tømrer Tom |
| 8 | Ydervægge | 2019-07-10 → 2019-07-11 (+1d) |  |  |  | resources none → Murer Mads |
| 9 | Tagkonstruktioner | 2019-07-10 → 2019-07-11 (+1d) |  |  |  | resources none → Tømrer Tom |
| 10 | Rejsegilde |  | 2019-07-12 → 2019-07-15 (+3d) |  |  | resources none → Arkitekt Arne; Forplejning [10 Kuverter]; Jord og Beton Jette; Maler Morten; Murer Mads; Snedker Susanne; Tømrer Tom; Tømrer Torben; VVS Victoria |
| 11 | Taglægning | 2019-07-12 → 2019-07-16 (+4d) | 2019-07-26 → 2019-07-29 (+3d) |  |  | resources none → Tømrer Tom |
| 12 | Døre og vinduer | 2019-07-12 → 2019-07-16 (+4d) | 2019-07-16 → 2019-07-17 (+1d) |  | 7d → 6.75d | resources none → Tømrer Tom |
| 13 | Faskine | 2019-07-01 → 2019-07-02 (+1d) | 2019-07-02 → 2019-07-04 (+2d) |  |  | resources none → Gravemaskine; Jord og Beton Jette |
| 14 | Tagrender | 2019-07-12 → 2019-07-16 (+4d) | 2019-07-12 → 2019-07-16 (+4d) |  |  | resources none → VVS Victoria |
| 15 | Maling udvendigt | 2019-07-25 → 2019-07-26 (+1d) | 2019-07-26 → 2019-07-29 (+3d) |  |  | resources none → Maling [10 Liter]; Maler Morten |
| 16 | Maling indvendigt | 2019-07-16 → 2019-07-18 (+2d) | 2019-07-18 → 2019-07-19 (+1d) |  | 7d → 6.75d | resources none → Maler Morten |
| 17 | Gulv | 2019-07-17 → 2019-07-19 (+2d) | 2019-07-18 → 2019-07-22 (+4d) |  | 7d → 6.75d | resources none → Snedker Susanne |
| 18 | Indvielse | 2019-07-29 → 2019-07-30 (+1d) | 2019-07-29 → 2019-07-31 (+2d) |  |  | resources none → Arkitekt Arne; Betonblander; Forplejning [20 Kuverter]; Gravemaskine; Jord og Beton Jette; Maler Morten; Murer Mads; Snedker Susanne; Tømrer Tom; Tømrer Torben; VVS Victoria |

## Version 4 (saved 2020-09-04, file 12B – Opfølgning II.mpp)

Last finish 2019-07-31 → 2019-08-01 (+1d). Complete tasks 0 → 9.

Changed:

| ID | Task | Start | Finish | Duration | Complete | Total float | Predecessors | Other |
| --- | --- | --- | --- | --- | --- | --- | --- | --- |
| 1 | Tegning | 2019-06-20 A | 2019-06-26 A |  | 0% → 100% | 0d → none |  | baseline start none → 2019-06-20; baseline finish none → 2019-06-26 |
| 2 | **Fundament** | 2019-06-28 A | 2019-07-08 A |  | 0% → 100% | 0d → none |  | baseline start none → 2019-06-28; baseline finish none → 2019-07-08 |
| 3 | Udgravning | 2019-06-28 A | 2019-07-02 A |  | 0% → 100% | 0d → none |  | baseline start none → 2019-06-28; baseline finish none → 2019-07-02 |
| 4 | Støbning | 2019-07-02 A | 2019-07-03 A |  | 0% → 100% | 0d → none |  | baseline start none → 2019-07-02; baseline finish none → 2019-07-03 |
| 5 | Afbinding | 2019-07-03 A | 2019-07-08 A |  | 0% → 100% | 0d → none |  | baseline start none → 2019-07-03; baseline finish none → 2019-07-08 |
| 6 | **Råhus** | 2019-07-08 A | 2019-07-12 → 2019-07-15 A (+3d) | 4.25d → 5d | 0% → 100% | 0d → none |  | baseline start none → 2019-07-08; baseline finish none → 2019-07-12 |
| 7 | Bærende konstruktioner | 2019-07-08 A | 2019-07-11 → 2019-07-12 A (+1d) | 3d → 4d | 0% → 100% | 0d → none |  | resources Tømrer Tom → Tømrer Torben; baseline start none → 2019-07-08; baseline finish none → 2019-07-11 |
| 8 | Ydervægge | 2019-07-11 A | 2019-07-12 → 2019-07-15 A (+3d) |  | 0% → 100% | 0d → none |  | baseline start none → 2019-07-11; baseline finish none → 2019-07-12 |
| 9 | Tagkonstruktioner | 2019-07-11 A | 2019-07-12 → 2019-07-15 A (+3d) |  | 0% → 100% | 0d → none |  | baseline start none → 2019-07-11; baseline finish none → 2019-07-12 |
| 10 | Rejsegilde | 2019-07-12 → 2019-07-15 A (+3d) | 2019-07-15 → 2019-07-16 A (+1d) |  | 0% → 100% | 0d → none |  | baseline start none → 2019-07-12; baseline finish none → 2019-07-15 |
| 11 | Taglægning |  | 2019-07-29 → 2019-07-30 (+1d) |  |  |  |  | baseline start none → 2019-07-16; baseline finish none → 2019-07-29 |
| 12 | Døre og vinduer |  | 2019-07-17 → 2019-07-19 (+2d) |  |  | 6.75d → 6.5d |  | resources Tømrer Tom → Snedker Susanne; baseline start none → 2019-07-16; baseline finish none → 2019-07-17 |
| 13 | Faskine | 2019-07-02 → 2019-07-03 A (+1d) | 2019-07-04 → 2019-07-05 A (+1d) |  | 0% → 100% | 15.38d → none | 3 → 4 | baseline start none → 2019-07-03; baseline finish none → 2019-07-05 |
| 14 | Tagrender |  | 2019-07-16 → 2019-07-17 (+1d) |  |  |  |  | baseline start none → 2019-07-16; baseline finish none → 2019-07-16 |
| 15 | Maling udvendigt | 2019-07-26 → 2019-07-29 (+3d) | 2019-07-29 → 2019-07-30 (+1d) |  |  |  |  | baseline start none → 2019-07-26; baseline finish none → 2019-07-29 |
| 16 | Maling indvendigt | 2019-07-18 → 2019-07-19 (+1d) | 2019-07-19 → 2019-07-23 (+4d) |  |  | 6.75d → 6.5d |  | baseline start none → 2019-07-18; baseline finish none → 2019-07-19 |
| 17 | Gulv | 2019-07-19 → 2019-07-22 (+3d) | 2019-07-22 → 2019-07-23 (+1d) |  |  | 6.75d → 6.5d |  | baseline start none → 2019-07-19; baseline finish none → 2019-07-22 |
| 18 | Indvielse | 2019-07-30 → 2019-07-31 (+1d) | 2019-07-31 → 2019-08-01 (+1d) |  |  |  |  | baseline start none → 2019-07-30; baseline finish none → 2019-07-31 |

## Version 5 (saved 2020-09-04, file 11D - Projektbilleder.mpp)

Last finish 2019-08-01 → 2019-08-05 (+4d). Complete tasks 9 → 0.

Added:

| ID | Task | Duration | Start | Finish |
| --- | --- | --- | --- | --- |
| 11 | **Ydre konstruktioner** | 10d | 2019-07-22 | 2019-08-05 |
| 17 | **Maling og gulv** | 5.5d | 2019-07-26 | 2019-08-05 |

Changed:

| ID | Task | Start | Finish | Duration | Complete | Total float | Predecessors | Other |
| --- | --- | --- | --- | --- | --- | --- | --- | --- |
| 1 | Tegning | 2019-06-20 A → 2019-06-20 | 2019-06-26 A → 2019-06-25 (-1d) | 3d → 4d | 100% → 0% | none → 0d |  | resources Arkitekt Arne → none; baseline start 2019-06-20 → none; baseline finish 2019-06-26 → none |
| 2 | **Fundament** | 2019-06-28 A → 2019-06-28 | 2019-07-08 A → 2019-07-08 | 6d → 7d | 100% → 0% | none → 0d |  | baseline start 2019-06-28 → none; baseline finish 2019-07-08 → none |
| 3 | Udgravning | 2019-06-28 A → 2019-06-28 | 2019-07-02 A → 2019-07-01 (-1d) |  | 100% → 0% | none → 0d |  | resources Gravemaskine; Jord og Beton Jette → none; baseline start 2019-06-28 → none; baseline finish 2019-07-02 → none |
| 4 | Støbning | 2019-07-02 A → 2019-07-02 | 2019-07-03 A → 2019-07-03 | 1d → 2d | 100% → 0% | none → 0d |  | resources Beton [2 Kubikmeter]; Betonblander; Jord og Beton Jette → none; baseline start 2019-07-02 → none; baseline finish 2019-07-03 → none |
| 5 | Afbinding | 2019-07-03 A → 2019-07-03 | 2019-07-08 A → 2019-07-08 |  | 100% → 0% | none → 1.88d |  | baseline start 2019-07-03 → none; baseline finish 2019-07-08 → none |
| 6 | **Råhus** | 2019-07-08 A → 2019-07-09 (+1d) | 2019-07-15 A → 2019-07-22 (+7d) | 5d → 9.75d | 100% → 0% | none → 0d |  | baseline start 2019-07-08 → none; baseline finish 2019-07-12 → none |
| 7 | Bærende konstruktioner | 2019-07-08 A → 2019-07-09 (+1d) | 2019-07-12 A → 2019-07-15 (+3d) | 4d → 5d | 100% → 0% | none → 0d |  | resources Tømrer Torben → none; baseline start 2019-07-08 → none; baseline finish 2019-07-11 → none |
| 8 | Ydervægge | 2019-07-11 A → 2019-07-12 (+1d) | 2019-07-15 A → 2019-07-18 (+3d) | 2d → 4d | 100% → 0% | none → 0d |  | resources Murer Mads → none; baseline start 2019-07-11 → none; baseline finish 2019-07-12 → none |
| 9 | Tagkonstruktioner | 2019-07-11 A → 2019-07-12 (+1d) | 2019-07-15 A → 2019-07-22 (+7d) | 2d → 6d | 100% → 0% | none → 0d |  | resources Tømrer Tom → none; baseline start 2019-07-11 → none; baseline finish 2019-07-12 → none |
| 10 | Rejsegilde | 2019-07-15 A → 2019-07-22 (+7d) | 2019-07-16 A → 2019-07-22 (+6d) |  | 100% → 0% | none → 0d |  | resources Arkitekt Arne; Forplejning [10 Kuverter]; Jord og Beton Jette; Maler Morten; Murer Mads; Snedker Susanne; Tømrer Tom; Tømrer Torben; VVS Victoria → none; baseline start 2019-07-12 → none; baseline finish 2019-07-15 → none |
| 12 | Taglægning | 2019-07-16 → 2019-07-22 (+6d) | 2019-07-30 → 2019-08-05 (+6d) |  |  |  |  | resources Tømrer Tom → none; baseline start 2019-07-16 → none; baseline finish 2019-07-29 → none |
| 13 | Døre og vinduer | 2019-07-16 → 2019-07-22 (+6d) | 2019-07-19 → 2019-07-26 (+7d) | 2d → 4d |  | 6.5d → 0.5d |  | resources Snedker Susanne → none; baseline start 2019-07-16 → none; baseline finish 2019-07-17 → none |
| 14 | Faskine | 2019-07-03 A → 2019-07-22 (+19d) | 2019-07-05 A → 2019-07-24 (+19d) |  | 100% → 0% | none → 2.38d | 4 → 10 | resources Gravemaskine; Jord og Beton Jette → none; baseline start 2019-07-03 → none; baseline finish 2019-07-05 → none |
| 15 | Tagrender | 2019-07-16 → 2019-07-24 (+8d) | 2019-07-17 → 2019-07-25 (+8d) |  |  | 8.12d → 2.38d |  | resources VVS Victoria → none; baseline start 2019-07-16 → none; baseline finish 2019-07-16 → none |
| 16 | Maling udvendigt | 2019-07-29 → 2019-07-25 (-4d) | 2019-07-30 → 2019-07-31 (+1d) | 10h → 4d |  | 0d → 2.38d | 15, 12FF → 15 | resources Maling [10 Liter]; Maler Morten → none; baseline start 2019-07-26 → none; baseline finish 2019-07-29 → none |
| 18 | Maling indvendigt | 2019-07-19 → 2019-07-26 (+7d) | 2019-07-23 → 2019-08-02 (+10d) | 2d → 5d |  | 6.5d → 0.5d |  | resources Maler Morten → none; baseline start 2019-07-18 → none; baseline finish 2019-07-19 → none |
| 19 | Gulv | 2019-07-22 → 2019-07-31 (+9d) | 2019-07-23 → 2019-08-05 (+13d) | 1d → 3d |  | 6.5d → 0.5d |  | resources Snedker Susanne → none; baseline start 2019-07-19 → none; baseline finish 2019-07-22 → none |
| 20 | Indvielse | 2019-07-31 → 2019-08-05 (+5d) | 2019-08-01 → 2019-08-05 (+4d) |  |  | 0d → 0.5d |  | resources Arkitekt Arne; Betonblander; Forplejning [20 Kuverter]; Gravemaskine; Jord og Beton Jette; Maler Morten; Murer Mads; Snedker Susanne; Tømrer Tom; Tømrer Torben; VVS Victoria → none; baseline start 2019-07-30 → none; baseline finish 2019-07-31 → none |

## Version 6 (saved 2021-09-03, file 03A - Justering af k慸er.mpp)

Last finish 2019-08-05 → 2019-07-30 (-6d).

Removed: 11 Ydre konstruktioner; 17 Maling og gulv

Changed:

| ID | Task | Start | Finish | Duration | Total float | Predecessors |
| --- | --- | --- | --- | --- | --- | --- |
| 1 | Tegning |  | 2019-06-25 → 2019-06-24 (-1d) | 4d → 3d |  |  |
| 2 | **Fundament** | 2019-06-28 → 2019-06-25 (-3d) | 2019-07-08 → 2019-07-04 (-4d) | 7d → 8d |  | 1FS+2d → 1 |
| 3 | Udgravning | 2019-06-28 → 2019-06-25 (-3d) | 2019-07-01 → 2019-06-26 (-5d) |  |  |  |
| 4 | Støbning | 2019-07-02 → 2019-06-27 (-5d) | 2019-07-03 → 2019-06-27 (-6d) | 2d → 1d |  |  |
| 5 | Afbinding | 2019-07-03 → 2019-06-28 (-5d) | 2019-07-08 → 2019-07-04 (-4d) | 5ed → 5d | 1.88d → 0d |  |
| 6 | **Råhus** | 2019-07-09 → 2019-07-05 (-4d) | 2019-07-22 → 2019-07-15 (-7d) | 9.75d → 7d |  |  |
| 7 | Bærende konstruktioner | 2019-07-09 → 2019-07-05 (-4d) | 2019-07-15 → 2019-07-09 (-6d) | 5d → 3d |  |  |
| 8 | Ydervægge | 2019-07-12 → 2019-07-10 (-2d) | 2019-07-18 → 2019-07-11 (-7d) | 4d → 2d |  | 7FS-2.5% → 7 |
| 9 | Tagkonstruktioner |  | 2019-07-22 → 2019-07-15 (-7d) | 6d → 2d |  | 8SS → 8 |
| 10 | Rejsegilde | 2019-07-22 → 2019-07-15 (-7d) | 2019-07-22 → 2019-07-15 (-7d) |  |  |  |
| 11 | Taglægning | 2019-07-22 → 2019-07-16 (-6d) | 2019-08-05 → 2019-07-17 (-19d) | 10d → 2d |  |  |
| 12 | Døre og vinduer | 2019-07-22 → 2019-07-18 (-4d) | 2019-07-26 → 2019-07-19 (-7d) | 4d → 2d | 0.5d → 0d | 11SS → 11 |
| 13 | Faskine |  | 2019-07-24 → 2019-07-23 (-1d) |  | 2.38d → 0d | 10 → 12 |
| 14 | Tagrender |  | 2019-07-25 → 2019-07-24 (-1d) |  | 2.38d → 0d | 13, 12SS → 13 |
| 15 | Maling indvendigt | 2019-07-26 → 2019-07-24 (-2d) | 2019-08-02 → 2019-07-26 (-7d) | 5d → 2d | 0.5d → 0d | 12 → 14 |
| 16 | Maling udvendigt | 2019-07-25 → 2019-07-26 (+1d) | 2019-07-31 → 2019-07-29 (-2d) | 4d → 10h | 2.38d → 0d | 14 → 15 |
| 17 | Gulv | 2019-07-31 → 2019-07-29 (-2d) | 2019-08-05 → 2019-07-30 (-6d) | 3d → 1d | 0.5d → 0d | 15FS-5% → 16 |
| 18 | Indvielse | 2019-08-05 → 2019-07-30 (-6d) | 2019-08-05 → 2019-07-30 (-6d) |  | 0.5d → 0d | 17, 16FS+1d → 17 |

## Version 7 (saved 2021-09-03, file 03B - Justering af opgaveafh憂gigheder.mpp)

Last finish 2019-07-30 → 2019-07-25 (-5d).

Changed:

| ID | Task | Start | Finish | Duration | Total float | Predecessors |
| --- | --- | --- | --- | --- | --- | --- |
| 6 | **Råhus** |  | 2019-07-15 → 2019-07-11 (-4d) | 7d → 5d |  |  |
| 9 | Tagkonstruktioner | 2019-07-12 → 2019-07-10 (-2d) | 2019-07-15 → 2019-07-11 (-4d) |  |  | 8 → 8SS |
| 10 | Rejsegilde | 2019-07-15 → 2019-07-11 (-4d) | 2019-07-15 → 2019-07-11 (-4d) |  |  |  |
| 11 | Taglægning | 2019-07-16 → 2019-07-12 (-4d) | 2019-07-17 → 2019-07-25 (+8d) | 2d → 10d |  |  |
| 12 | Døre og vinduer | 2019-07-18 → 2019-07-12 (-6d) | 2019-07-19 → 2019-07-15 (-4d) |  | 0d → 4.75d | 11 → 11SS |
| 13 | Faskine | 2019-07-22 → 2019-06-27 (-25d) | 2019-07-23 → 2019-06-28 (-25d) |  | 0d → 19.38d | 12 → 3 |
| 14 | Tagrender | 2019-07-24 → 2019-07-12 (-12d) | 2019-07-24 → 2019-07-12 (-12d) |  | 0d → 10.38d | 13 → 13, 12SS |
| 15 | Maling indvendigt | 2019-07-24 → 2019-07-16 (-8d) | 2019-07-26 → 2019-07-17 (-9d) |  | 0d → 4.75d | 14 → 12 |
| 16 | Maling udvendigt | 2019-07-26 → 2019-07-24 (-2d) | 2019-07-29 → 2019-07-25 (-4d) |  |  | 15 → 15, 11FF |
| 17 | Gulv | 2019-07-29 → 2019-07-18 (-11d) | 2019-07-30 → 2019-07-18 (-12d) |  | 0d → 5d | 16 → 15 |
| 18 | Indvielse | 2019-07-30 → 2019-07-25 (-5d) | 2019-07-30 → 2019-07-25 (-5d) |  |  | 17 → 17, 16 |

## Version 8 (saved 2021-09-03, file 11A - Udskrivning - Renoveringsprojekt.mpp)

Last finish 2019-07-25 → 2018-04-12 (-469d).

Changed:

| ID | Task | Start | Finish | Duration | Total float | Predecessors | Other |
| --- | --- | --- | --- | --- | --- | --- | --- |
| 1 | Tegning | 2019-06-20 → 2018-03-05 (-472d) | 2019-06-24 → 2018-03-09 (-472d) |  |  |  | resources none → Arkitekt Arne |
| 2 | **Fundament** | 2019-06-25 → 2018-03-13 (-469d) | 2019-07-04 → 2018-03-21 (-470d) | 8d → 6d |  | 1 → 1FS+2d |  |
| 3 | Udgravning | 2019-06-25 → 2018-03-13 (-469d) | 2019-06-26 → 2018-03-15 (-468d) |  |  |  | resources none → Gravemaskine; Jord og beton Jette |
| 4 | Støbning | 2019-06-27 → 2018-03-15 (-469d) | 2019-06-27 → 2018-03-16 (-468d) |  |  |  | resources none → Jord og beton Jette; Betonblander |
| 5 | Afbinding | 2019-06-28 → 2018-03-16 (-469d) | 2019-07-04 → 2018-03-21 (-470d) | 5d → 5ed |  |  |  |
| 6 | **Råhus** | 2019-07-05 → 2018-03-21 (-471d) | 2019-07-11 → 2018-03-28 (-470d) | 5d → 4.5d |  | 2 → 5 |  |
| 7 | Bærende konstruktioner | 2019-07-05 → 2018-03-21 (-471d) | 2019-07-09 → 2018-03-26 (-470d) |  |  |  | resources none → Tømrer Tom |
| 8 | Ydervægge | 2019-07-10 → 2018-03-26 (-471d) | 2019-07-11 → 2018-03-27 (-471d) |  |  | 7 → 7FS-2.5% | resources none → Murer Mads |
| 9 | Tagkonstruktioner | 2019-07-10 → 2018-03-26 (-471d) | 2019-07-11 → 2018-03-28 (-470d) |  |  |  | resources none → Snedker Susanne |
| 10 | Rejsegilde | 2019-07-11 → 2018-03-28 (-470d) | 2019-07-11 → 2018-03-28 (-470d) |  |  | 6 → 9 | resources none → Arkitekt Arne; Jord og beton Jette; Maler Morten; Murer Mads; Snedker Susanne; Tømrer Tom; VVS Victoria |
| 11 | Taglægning | 2019-07-12 → 2018-03-28 (-471d) | 2019-07-25 → 2018-04-11 (-470d) |  |  |  | resources none → Tømrer Tom |
| 12 | Døre og vinduer | 2019-07-12 → 2018-03-28 (-471d) | 2019-07-15 → 2018-03-30 (-472d) |  | 4.75d → 4.5d |  | resources none → Snedker Susanne |
| 13 | Faskine | 2019-06-27 → 2018-03-16 (-468d) | 2019-06-28 → 2018-03-20 (-465d) |  | 19.38d → 11.12d | 3 → 4 | resources none → Gravemaskine; Jord og beton Jette |
| 14 | Tagrender | 2019-07-12 → 2018-03-28 (-471d) | 2019-07-12 → 2018-03-28 (-471d) |  | 10.38d → 5.62d |  | resources none → VVS Victoria |
| 15 | Maling udvendigt | 2019-07-24 → 2018-03-28 (-483d) | 2019-07-25 → 2018-03-30 (-482d) |  | 0d → 5.62d | 17, 11FF → 14 | resources none → Maler Morten |
| 16 | Gulv | 2019-07-18 → 2018-03-30 (-475d) | 2019-07-18 → 2018-04-02 (-472d) |  | 5d → 4.62d | 17 → 15FS-5%, 12 | resources none → Snedker Susanne |
| 17 | Maling indvendigt | 2019-07-16 → 2018-04-09 (-463d) | 2019-07-17 → 2018-04-11 (-462d) |  | 4.75d → 0d | 12 → 16, 11FF | resources none → Maler Morten |
| 18 | Indvielse | 2019-07-25 → 2018-04-12 (-469d) | 2019-07-25 → 2018-04-12 (-469d) |  |  | 16, 15 → 17FS+1d | resources none → Jord og beton Jette; Maler Morten; Murer Mads; Snedker Susanne; Tømrer Tom; VVS Victoria; Arkitekt Arne |

## Version 9 (saved 2021-09-13, file 12A - Opf沴gning I.mpp)

Last finish 2018-04-12 → 2019-07-31 (+475d).

Changed:

| ID | Task | Start | Finish | Duration | Total float | Predecessors | Other |
| --- | --- | --- | --- | --- | --- | --- | --- |
| 1 | Tegning | 2018-03-05 → 2019-06-20 (+472d) | 2018-03-09 → 2019-06-26 (+474d) |  |  |  |  |
| 2 | **Fundament** | 2018-03-13 → 2019-06-28 (+472d) | 2018-03-21 → 2019-07-08 (+474d) |  |  |  |  |
| 3 | Udgravning | 2018-03-13 → 2019-06-28 (+472d) | 2018-03-15 → 2019-07-02 (+474d) |  |  |  | resources Gravemaskine; Jord og beton Jette → Gravemaskine; Jord og Beton Jette |
| 4 | Støbning | 2018-03-15 → 2019-07-02 (+474d) | 2018-03-16 → 2019-07-03 (+474d) |  |  |  | resources Jord og beton Jette; Betonblander → Beton [2 Kubikmeter]; Betonblander; Jord og Beton Jette |
| 5 | Afbinding | 2018-03-16 → 2019-07-03 (+474d) | 2018-03-21 → 2019-07-08 (+474d) |  |  |  |  |
| 6 | **Råhus** | 2018-03-21 → 2019-07-08 (+474d) | 2018-03-28 → 2019-07-12 (+471d) | 4.5d → 4.25d |  | 5 → 2 |  |
| 7 | Bærende konstruktioner | 2018-03-21 → 2019-07-08 (+474d) | 2018-03-26 → 2019-07-11 (+472d) |  |  |  | resources Tømrer Tom → Tømrer Torben |
| 8 | Ydervægge | 2018-03-26 → 2019-07-11 (+472d) | 2018-03-27 → 2019-07-12 (+472d) |  |  |  |  |
| 9 | Tagkonstruktioner | 2018-03-26 → 2019-07-11 (+472d) | 2018-03-28 → 2019-07-12 (+471d) |  |  |  | resources Snedker Susanne → Tømrer Tom |
| 10 | Rejsegilde | 2018-03-28 → 2019-07-12 (+471d) | 2018-03-28 → 2019-07-15 (+474d) |  |  | 9 → 6 | resources Arkitekt Arne; Jord og beton Jette; Maler Morten; Murer Mads; Snedker Susanne; Tømrer Tom; VVS Victoria → Arkitekt Arne; Forplejning [10 Kuverter]; Jord og Beton Jette; Maler Morten; Murer Mads; Snedker Susanne; Tømrer Tom; Tømrer Torben; VVS Victoria |
| 11 | Taglægning | 2018-03-28 → 2019-07-16 (+475d) | 2018-04-11 → 2019-07-29 (+474d) |  |  |  |  |
| 12 | Døre og vinduer | 2018-03-28 → 2019-07-16 (+475d) | 2018-03-30 → 2019-07-18 (+475d) |  | 4.5d → 6.5d |  |  |
| 13 | Faskine | 2018-03-16 → 2019-07-03 (+474d) | 2018-03-20 → 2019-07-05 (+472d) |  | 11.12d → 14.38d |  | resources Gravemaskine; Jord og beton Jette → Gravemaskine; Jord og Beton Jette |
| 14 | Tagrender | 2018-03-28 → 2019-07-16 (+475d) | 2018-03-28 → 2019-07-16 (+475d) |  | 5.62d → 8.12d |  |  |
| 15 | Maling udvendigt | 2018-03-28 → 2019-07-26 (+485d) | 2018-03-30 → 2019-07-29 (+486d) |  | 5.62d → 0d | 14 → 14, 11FF | resources Maler Morten → Maling [10 Liter]; Maler Morten |
| 16 | Maling indvendigt | 2018-04-09 → 2019-07-18 (+465d) | 2018-04-11 → 2019-07-22 (+467d) |  | 0d → 6.5d | 17, 11FF → 12 |  |
| 17 | Gulv | 2018-03-30 → 2019-07-19 (+476d) | 2018-04-02 → 2019-07-22 (+476d) |  | 4.62d → 6.5d | 15FS-5%, 12 → 16FS-5% |  |
| 18 | Indvielse | 2018-04-12 → 2019-07-30 (+474d) | 2018-04-12 → 2019-07-31 (+475d) |  |  | 16FS+1d → 17, 15FS+1d | resources Jord og beton Jette; Maler Morten; Murer Mads; Snedker Susanne; Tømrer Tom; VVS Victoria; Arkitekt Arne → Arkitekt Arne; Betonblander; Forplejning [20 Kuverter]; Gravemaskine; Jord og Beton Jette; Maler Morten; Murer Mads; Snedker Susanne; Tømrer Tom; Tømrer Torben; VVS Victoria |
